# EGT-Project-Plan

Schedule from MS Project, 2007-02-16 to 2007-06-14.
test

## Calendars

- Standard: Mon-Fri 08:00-12:00, 13:00-17:00; Sat-Sun off.

## Resources

| Resource |
| --- |
| Slavi Marinov |
| Slavi |
| Slavi, Jordan |
| Slavi, ? |
| NASD |
| ? |
| Slavi, Jordan, ? |
| Katia |
| Slavi, Jordan, Katia |
| Slavi, Katia |
| EGT |

## Schedule

| ID | WBS | Task | Duration | Start | Finish | Predecessors | Total slack | Free slack | Constraint | Resources | Work |
| --- | --- | --- | --- | --- | --- | --- | --- | --- | --- | --- | --- |
| 1 | 1 | **Finding Candidates** | 12d | 2007-02-16 | 2007-03-05 |  | 3d | 0d | start no earlier than 2007-02-16 | NASD | 272h |
| 2 | 1.1 | Posting advertisments | 3d | 2007-02-16 | 2007-02-20 |  | 3d | 0d |  | NASD | 24h |
| 3 | 1.2 | Collecting candidates (CVs) | 5d | 2007-02-21 | 2007-02-27 | 2 | 3d | 0d |  | NASD | 40h |
| 4 | 1.3 | Entrance exams | 2d | 2007-02-28 | 2007-03-01 | 3 | 3d | 0d |  | NASD | 16h |
| 5 | 1.4 | Interviews with candidates | 2d | 2007-03-02 | 2007-03-05 | 4 | 3d |  |  | NASD | 16h |
| 6 | 1.5 | Prepare Intro C++ materials | 10d | 2007-02-16 | 2007-03-01 |  | 2d |  |  | Katia | 80h |
| 7 | 2 | **Intro C++ Course** | 22d | 2007-03-06 | 2007-04-04 | 1 | 3d |  |  | Slavi, Jordan, Katia | 440h |
| 8 | 2.1 | Intro C++ (part 1) | 10d | 2007-03-06 | 2007-03-19 |  | 3d | 0d |  | Slavi, Jordan, Katia | 80h |
| 9 | 2.2 | Intermediate exam #1 | 1d | 2007-03-20 | 2007-03-20 | 8 | 3d | 0d |  | Slavi, Jordan, Katia | 8h |
| 10 | 2.3 | Intro C++ (part 2) | 10d | 2007-03-21 | 2007-04-03 | 9 | 3d | 0d |  | Slavi, Katia | 80h |
| 11 | 2.4 | Final exam | 1d | 2007-04-04 | 2007-04-04 | 10 | 3d |  |  | Slavi, Katia | 8h |
| 12 | 2.5 | Prepare Core C++ materials | 22d | 2007-03-06 | 2007-04-04 |  | 3d |  |  | Katia [50%] | 88h |
| 13 | 3 | Interviews with the best candidates | 4d | 2007-04-10 | 2007-04-13 | 7 | 0d |  | start no earlier than 2007-04-10 | EGT | 32h |
| 14 | 4 | **Core C++ Course** | 44d | 2007-04-16 | 2007-06-14 | 13 | 0d |  |  | Slavi, Katia | 864h |
| 15 | 4.1 | Prepare Core C++ materials | 40d | 2007-04-16 | 2007-06-08 |  | 4d |  |  | Katia [50%] | 160h |
| 16 | 4.2 | Core C++ (part 1) | 7d | 2007-04-16 | 2007-04-24 |  | 0d |  |  | Katia [50%]; Slavi [50%] | 56h |
| 17 | 4.3 | Intermediate exam #1 | 1d | 2007-04-25 | 2007-04-25 | 16 | 0d |  |  | Katia [50%]; Slavi [50%] | 8h |
| 18 | 4.4 | Core C++ (part 2) | 7d | 2007-04-26 | 2007-05-04 | 17 | 0d |  |  | Katia [50%]; Slavi [50%] | 56h |
| 19 | 4.5 | Intermediate exam #2 | 1d | 2007-05-07 | 2007-05-07 | 18 | 0d |  |  | Katia [50%]; Slavi [50%] | 8h |
| 20 | 4.6 | Core C++ (part 3) | 7d | 2007-05-08 | 2007-05-16 | 19 | 0d |  |  | Katia [50%]; Slavi [50%] | 56h |
| 21 | 4.7 | Intermediate exam #3 | 1d | 2007-05-17 | 2007-05-17 | 20 | 0d |  |  | Katia [50%]; Slavi [50%] | 8h |
| 22 | 4.8 | Core C++ (part 4) | 7d | 2007-05-18 | 2007-05-28 | 21 | 0d |  |  | Katia [50%]; Slavi [50%] | 56h |
| 23 | 4.9 | Intermediate exam #4 | 1d | 2007-05-29 | 2007-05-29 | 22 | 0d |  |  | Katia [50%]; Slavi [50%] | 8h |
| 24 | 4.10 | Practical project | 12d | 2007-05-30 | 2007-06-14 | 23 | 0d |  |  | Katia [50%]; Slavi [50%] | 96h |
